# CAÑETE V3.1

Schedule from MS Project, 2023-10-01 to 2024-10-25, status date 2023-07-31.

## Calendars

- Copia de Estándar: Mon-Fri 09:00-13:00, 15:00-19:00; Sat-Sun off. Exceptions (off unless hours are given): 2023-10-01 to 2024-10-25 09:00-13:00, 15:00-19:00.

## Schedule

| ID | WBS | Task | Type | Duration | Start | Finish | Predecessors | Baseline start | Baseline finish | Baseline duration | Total slack | Free slack | Constraint | UND | METRADO |
| --- | --- | --- | --- | --- | --- | --- | --- | --- | --- | --- | --- | --- | --- | --- | --- |
| 1 | 0 | PROYECTO HABILITACIÓN DE ACCESOS, PLATAFORMAS Y MOVIMIENTO DE TIERRAS III PARTE - CUENCA CAÑETE |  | 391d | 2023-10-01 | 2024-10-25 | 2 | 2023-09-01 | 2024-09-30 | 282d | 0d |  | start no earlier than 2023-10-01 |  |  |
| 2 | 1 | INICIO | milestone | 0d | 2023-10-01 | 2023-10-01 |  |  |  |  | 0d |  | start no later than 2023-10-01 |  |  |
| 3 | 1.00 | **Obras Provisionales** |  | 387d | 2023-10-01 | 2024-10-21 |  | 2023-12-01 | 2024-12-30 | 282d | -107d | 0d | finish no later than 2024-09-30 |  |  |
| 4 | 1.01 | Campamento Provisional de Obra |  | 30d | 2023-10-01 | 2023-10-30 |  | 2023-12-01 | 2024-12-30 | 282d | -107d | 0d | start no later than 2023-05-04 | glb | 1.00 |
| 5 | 1.02 | Movilización y Desmovilización de maquinaria pesada |  | 59d | 2023-10-01 | 2024-10-21 | 4SS | 2024-01-01 | 2024-02-12 | 30d | -21.19d | 0d | finish no earlier than 2024-09-25 | glb | 1.00 |
| 6 | 1.03 | Mejoramiento y Habilitación de caminos de acceso |  | 45d | 2023-10-16 | 2023-11-29 | 4SS+15d | 2024-02-12 | 2024-04-15 | 45d | 305.81d |  | finish no later than 2024-11-01 | km | 20.30 |
| 7 | 1.05 | Mantenimiento de caminos de acceso |  | 386d | 2023-10-01 | 2024-10-20 | 4SS, 5SS | 2024-03-11 | 2024-04-01 | 15d | -21d | 0d |  | mes | 15.00 |
| 8 | 1.06 | Habilitación de plataformas |  | 15d | 2023-10-01 | 2023-10-15 | 4SS | 2024-04-01 | 2024-04-10 | 7d | 172.81d |  | finish no later than 2024-04-05 | ha | 0.75 |
| 9 | 1.07 | Tubería HDPE Corrugada Ø=600mm, para caminos de acceso (o similar) |  | 6d | 2023-10-01 | 2023-10-06 |  | 2024-04-10 | 2024-04-18 | 6d | 187.81d |  | finish no later than 2024-04-11 |  | 140.00 |
| 10 | 1.08 | Tubería HDPE Corrugada Ø=1000mm, para caminos de acceso (o similar) |  | 16d | 2023-10-01 | 2023-10-16 | 7SS | 2024-04-01 | 2024-04-23 | 16d | 193.81d |  | finish no later than 2024-04-27 |  | 240.00 |
| 11 | 1.09 | Cruce provisional de rio |  | 30d | 2023-10-16 | 2023-11-14 | 4SS+15d | 2024-04-29 | 2024-09-02 | 90d | 292d |  | finish no later than 2024-09-01 | glb | 1.00 |
| 12 | 1.10 | Demolición de cruce provisional |  | 25d | 2024-09-01 | 2024-09-25 |  | 2024-04-01 | 2024-04-29 | 20d | 4.81d |  | start no earlier than 2024-09-01 | m3 | 1,350.00 |
| 13 | 2.00 | **Topografía** |  | 391d | 2023-10-01 | 2024-10-25 |  | 2023-12-01 | 2024-12-30 | 282d | 0d |  | start no earlier than 2023-09-01 |  |  |
| 14 | 2.01 | Trazo y replanteo inicial |  | 30d | 2023-10-01 | 2023-10-30 | 15SS | 2023-12-01 | 2024-01-11 | 30d | 59d |  | finish no later than 2023-12-28 | glb | 1.00 |
| 15 | 2.02 | Trazo y replanteo durante la obra |  | 391d | 2023-10-01 | 2024-10-25 |  | 2023-12-01 | 2024-12-30 | 282d | 0d |  | start no earlier than 2023-10-01 | mes | - |
| 16 | 3.00 | **Excavaciones** |  | 360d | 2023-10-01 | 2024-09-24 |  | 2023-12-01 | 2025-01-16 | 295d | -21d | 0d | finish no later than 2025-01-16 |  |  |
| 17 | 3.02 | Desbroce |  | 90d | 2023-10-16 | 2024-01-13 | 4SS+15d | 2024-02-02 | 2024-03-14 | 30d | 13d | 0d | finish no later than 2024-06-30 | ha | 30.30 |
| 18 | 3.03 | Remoción de dique existente |  | 120d | 2023-10-26 | 2024-02-22 | 17SS+10d | 2024-03-15 | 2024-03-28 | 10d | 158.81d |  | finish no later than 2024-07-30 | m3 | 79,341.98 |
| 19 | 3.04 | Excavación de cimentación |  | 253d | 2023-10-31 | 2024-09-22 | 17SS+15d | 2024-03-29 | 2024-05-09 | 30d | 13d | 0d |  | m3 | 442,562.30 |
| 20 | 3.05 | Perfilado y conformación de Plataforma de fundación |  | 253d | 2023-10-31 | 2024-09-22 | 19SS | 2024-05-10 | 2024-06-20 | 30d | 13d | 0d | finish no later than 2025-01-16 | m2 | 309,704.49 |
| 21 | 3.06 | Excavación de uña |  | 321d | 2023-11-09 | 2024-09-24 | 28SS+7d | 2024-06-21 | 2024-06-24 | 2d | 90d |  | finish no later than 2025-01-16 | m3 | 175,977.99 |
| 22 | 3.07 | Excavación bajo nivel freático |  | 55d | 2023-11-20 | 2024-01-13 | 19SS+20d | 2024-06-25 | 2024-07-22 | 20d | 191d |  | finish no later than 2024-07-22 | m3 | - |
| 23 | 3.08 | Conformación de material excedente en DME |  | 330d | 2023-10-31 | 2024-09-24 | 19SS | 2024-07-23 | 2024-10-14 | 60d | 90d |  | finish no earlier than 2024-08-26 | m3 | 653,112.02 |
| 24 | 3.09 | Conformación de material excedente en DMO |  | 90d | 2023-10-23 | 2024-01-20 | 17SS+7d | 2024-10-15 | 2025-01-16 | 68d | 338d |  | finish no later than 2025-01-16 | m3 | 95,703.80 |
| 25 | 3.10 | Excavación localizada - Sobreexcavación |  | 40d | 2023-11-30 | 2024-01-08 | 19SS+30d | 2024-05-10 | 2024-07-04 | 40d | 350d |  | finish no later than 2025-01-16 | m3 | 60,695.49 |
| 26 | 3.13 | Descolmatación |  | 16d | 2023-10-01 | 2023-10-16 | 7SS, 4SS | 2024-03-15 | 2024-04-05 | 16d | -21d | 0d | finish no later than 2023-09-24 | m3 | 16,631.33 |

| ID | WBS | Task | Duration | Start | Finish | Predecessors | Baseline start | Baseline finish | Baseline duration | Total slack | Free slack | Constraint | UND | METRADO |
| --- | --- | --- | --- | --- | --- | --- | --- | --- | --- | --- | --- | --- | --- | --- |
| 27 | 4.00 | **Rellenos** | 335d | 2023-11-02 | 2024-10-01 |  | 2024-03-29 | 2024-11-21 | 170d | 19d |  | finish no later than 2024-11-21 |  |  |
| 28 | 4.01 | Relleno con material granular (incluye extracción de material, zarandeo y combinación de material) | 335d | 2023-11-02 | 2024-10-01 | 20SS+2d | 2024-07-23 | 2024-09-23 | 45d | 19d | 0d | finish no later than 2024-11-21 | m3 | 254,270.42 |
| 29 | 4.02 | Relleno sin compactar | 315d | 2023-11-02 | 2024-09-11 | 28SS | 2024-07-23 | 2024-10-07 | 55d | 63d | 0d | start no earlier than 2023-10-17 | m3 | 68,605.49 |
| 30 | 4.03 | Relleno afirmado | 315d | 2023-11-02 | 2024-09-11 | 29SS, 28SS | 2024-05-10 | 2024-06-27 | 35d | 63d | 0d | finish no earlier than 2024-09-10 | m3 | 12,195.58 |
| 31 | 4.04 | Perfilado de Talud del dique | 315d | 2023-11-02 | 2024-09-11 | 29SS, 28SS | 2024-03-29 | 2024-06-20 | 60d | 63d | 0d | finish no earlier than 2024-08-05 | m2 | 151,186.58 |
| 32 | 4.05 | Relleno con material seleccionado (incluye extracción de material, zarandeo y combinación de material) en Sobreexcavación | 315d | 2023-11-16 | 2024-09-25 | 144SS+7d | 2024-07-05 | 2024-11-21 | 100d | 38d | 0d | finish no earlier than 2024-08-15 | m3 | 72,211.84 |
| 33 | 4.06 | Grava para drenaje | 283d | 2023-11-04 | 2024-08-12 | 28SS+2d | 2024-10-08 | 2024-10-31 | 18d | 93d |  | finish no earlier than 2024-08-10 | m3 | 13,148.81 |
| 34 | 5.00 | **Geotextil** | 330d | 2023-11-02 | 2024-09-26 |  | 2024-11-01 | 2025-01-30 | 65d | -31d | 0d | finish no later than 2025-01-30 |  |  |
| 35 | 5.01 | Instalación de geotextil 400 gr/m2 | 330d | 2023-11-02 | 2024-09-26 | 31SS | 2024-11-08 | 2025-01-30 | 60d | 98d | 0d | finish no earlier than 2024-09-10 | m2 | 427,174.85 |
| 36 | 5.02 | Zanja de anclaje | 330d | 2023-11-02 | 2024-09-26 | 31SS | 2024-11-01 | 2024-11-07 | 5d | -31d | 0d | finish no later than 2024-08-26 | m3 | 2,298.67 |
| 37 | 6.00 | **Infraestructura verde y paisajismo** | 241d | 2024-01-02 | 2024-08-29 |  | 2023-12-01 | 2024-05-16 | 120d | -21.19d | 0d | finish no later than 2024-09-30 |  |  |
| 38 | 6.01 | **Revegetación / Reforestación de la ribera** | 103d | 2024-01-02 | 2024-04-13 |  | 2023-12-01 | 2024-03-19 | 78d | -21.19d | 0d | finish no later than 2024-09-30 |  |  |
| 39 | 06.01.01 | **Preparación del Terreno** | 103d | 2024-01-02 | 2024-04-13 |  | 2023-12-01 | 2024-03-14 | 75d | -21.19d | 0d | finish no later than 2024-03-23 |  |  |
| 40 | 06.01.01.01 | Ubicación y delimitación de la zona de trabajo | 10d | 2024-01-02 | 2024-01-11 |  | 2023-12-01 | 2023-12-14 | 10d | -21.19d | 0d | start no earlier than 2024-01-02 | m2 | 137,144.56 |
| 41 | 06.01.01.02 | Trazado, marcación y estacado | 10d | 2024-01-12 | 2024-01-21 | 40 | 2023-12-15 | 2023-12-28 | 10d | -21.19d | 0d | finish no later than 2024-01-28 | m2 | 137,144.56 |
| 42 | 06.01.01.03 | Limpieza y desbroce del terreno con medios manuales | 8d | 2024-01-22 | 2024-01-29 | 41 | 2023-12-29 | 2024-01-09 | 8d | -21.19d | 0d | finish no later than 2024-02-05 | m2 | 3,136.23 |
| 43 | 06.01.01.04 | Eliminación de materiales de desbroce (Incluye Transporte) | 2d | 2024-01-30 | 2024-01-31 | 42 | 2024-01-10 | 2024-01-11 | 2d | -21.19d | 0d | finish no later than 2024-02-07 | m3 | 627.25 |
| 44 | 06.01.01.05 | Despedregado del terreno con medios manuales | 5d | 2024-02-01 | 2024-02-05 | 43 | 2024-01-10 | 2024-01-16 | 5d | -21.19d | 0d | finish no later than 2024-02-10 | m2 | 3,136.23 |
| 45 | 06.01.01.06 | Remoción del terreno con medios manuales con profundidad hasta 25 cm | 5d | 2024-02-06 | 2024-02-10 | 44 | 2024-01-17 | 2024-01-23 | 5d | -21.19d | 0d | finish no later than 2024-02-15 | m2 | 0.00 |
| 46 | 06.01.01.07 | Rastrillado del terreno | 7d | 2024-02-11 | 2024-02-17 | 45 | 2024-01-24 | 2024-02-01 | 7d | -21.19d | 0d | finish no later than 2024-02-22 | m2 | 0.00 |
| 47 | 06.01.01.08 | Preparación y aporte del sustrato | 26d | 2024-02-18 | 2024-03-14 | 46 | 2024-02-02 | 2024-03-08 | 26d | -21.19d | 0d | finish no later than 2024-03-19 | m2 | 3,613.66 |
| 48 | 06.01.01.09 | Riego de áreas vegetadas con camión cisterna | 30d | 2024-03-15 | 2024-04-13 | 47 | 2024-02-02 | 2024-03-14 | 30d | -21.19d | 0d | finish no later than 2024-03-23 | mes | 3.00 |
| 49 | 06.01.02 | **Especies arbustivas** | 1d | 2024-03-15 | 2024-03-15 |  | 2024-03-15 | 2024-03-18 | 2d | 8.81d |  | finish no later than 2024-03-25 |  |  |
| 50 | 06.01.02.01 | Tessaria Integrifolia (Pájaro Bobo) Incluye siembra y transporte | 1d | 2024-03-15 | 2024-03-15 | 47 | 2024-03-15 | 2024-03-15 | 1d | 8.81d | 0d | finish no later than 2024-03-24 | und | 1,531.00 |
| 51 | 06.01.02.02 | Baccharis Latifolia (Chilco) Incluye siembra y transporte | 1d | 2024-03-15 | 2024-03-15 | 50SS | 2024-03-18 | 2024-03-18 | 1d | 9.81d | 0d | finish no later than 2024-03-25 | und | 1,531.00 |

| ID | WBS | Task | Duration | Start | Finish | Predecessors | Baseline start | Baseline finish | Baseline duration | Total slack | Free slack | Constraint | UND | METRADO |
| --- | --- | --- | --- | --- | --- | --- | --- | --- | --- | --- | --- | --- | --- | --- |
| 52 | 06.01.03 | **Especies arbóreas** | 1d | 2024-03-15 | 2024-03-15 |  | 2024-03-19 | 2024-03-19 | 1d | 10.81d |  | finish no later than 2024-09-30 |  |  |
| 53 | 06.01.03.01 | Schinus Molle (Molle) Incluye siembra y transporte | 1d | 2024-03-15 | 2024-03-15 | 50SS, 51SS | 2024-03-19 | 2024-03-19 | 1d | 198.81d |  | finish no later than 2024-09-30 | und | 2,248.00 |
| 54 | 06.01.03.02 | Acacia Macracantha (Huarango) Incluye siembra y transporte | 1d | 2024-03-15 | 2024-03-15 | 50SS, 51SS | 2024-03-19 | 2024-03-19 | 1d | 198.81d |  | finish no later than 2024-09-30 | und | 2,268.00 |
| 55 | 06.01.03.03 | Salix Humboldtiana (Sauce) Incluye siembra y transporte | 1d | 2024-03-15 | 2024-03-15 | 50SS, 51SS | 2024-03-19 | 2024-03-19 | 1d | 10.81d |  | finish no later than 2024-03-26 | und | 530.00 |
| 56 | 6.02 | **Arquitectura** | 98d | 2024-01-02 | 2024-04-08 |  | 2024-03-19 | 2024-05-16 | 43d | 83.81d |  | finish no later than 2024-09-30 |  |  |
| 57 | 06.02.01 | **Preparación del terreno** | 37d | 2024-01-02 | 2024-02-07 |  | 2024-03-19 | 2024-04-10 | 17d | 83.81d |  | finish no later than 2024-07-02 |  |  |
| 58 | 06.02.01.01 | Ubicación y delimitación de la zona de trabajo | 1d | 2024-01-02 | 2024-01-02 | 40SS | 2024-03-19 | 2024-03-19 | 1d | 83.81d |  | finish no later than 2024-03-26 | m2 | 160.07 |
| 59 | 06.02.01.02 | Limpieza y desbroce del terreno con medios manuales | 7d | 2024-01-22 | 2024-01-28 | 42SS | 2024-03-20 | 2024-03-28 | 7d | 146.81d |  | finish no later than 2024-06-23 | m2 | 160.07 |
| 60 | 06.02.01.03 | Eliminación de materiales de desbroce (Incluye Transporte) | 2d | 2024-01-30 | 2024-01-31 | 43SS | 2024-03-29 | 2024-04-01 | 2d | 145.81d |  | finish no later than 2024-06-25 | m3 | 32.01 |
| 61 | 06.02.01.04 | Despedregado del terreno con medios manuales | 7d | 2024-02-01 | 2024-02-07 | 44SS | 2024-04-02 | 2024-04-10 | 7d | 145.81d |  | finish no later than 2024-07-02 | m2 | 160.07 |
| 62 | 06.02.02 | **Trabajos provisionales** | 1d | 2024-01-02 | 2024-01-02 |  | 2024-03-19 | 2024-03-19 | 1d | 83.81d |  | finish no later than 2024-03-26 |  |  |
| 63 | 06.02.02.01 | Trazado y replanteo s/equipo con cal blanca | 1d | 2024-01-02 | 2024-01-02 | 40SS | 2024-03-19 | 2024-03-19 | 1d | 83.81d | 0d | finish no later than 2024-03-26 | m2 | 160.07 |
| 64 | 06.02.03 | **Pasarela** | 22d | 2024-03-15 | 2024-04-05 |  | 2024-04-11 | 2024-05-10 | 22d | 117.81d |  | finish no later than 2024-09-24 |  |  |
| 65 | 06.02.03.01 | Piso entablado de madera de sección 1” x 6” para pasarela elevada | 16d | 2024-03-15 | 2024-03-30 | 47 | 2024-04-11 | 2024-05-02 | 16d | 117.81d | 0d | finish no later than 2024-09-16 | m2 | 160.07 |
| 66 | 06.02.03.02 | Baranda de madera de huayruro de H=1.00 M, para pasarela | 6d | 2024-03-31 | 2024-04-05 | 65 | 2024-05-03 | 2024-05-10 | 6d | 117.81d | 0d | finish no later than 2024-09-24 |  | 121.57 |
| 67 | 06.02.04 | **Mobiliario Urbano** | 3d | 2024-04-06 | 2024-04-08 |  | 2024-05-13 | 2024-05-16 | 4d | 117.81d |  | finish no later than 2024-09-30 |  |  |
| 68 | 06.02.04.01 | Bancas de madera con respaldar. Tipo T1 | 1d | 2024-04-06 | 2024-04-06 | 66 | 2024-05-13 | 2024-05-13 | 1d | 117.81d | 0d | finish no later than 2024-09-25 | und | 2.00 |
| 69 | 06.02.04.02 | Papeleras de reciclaje de acabado de madera en estructura de 4 (75 Litros C/U) | 1d | 2024-04-07 | 2024-04-07 | 68 | 2024-05-14 | 2024-05-14 | 1d | 171.81d | 0d | finish no later than 2024-09-26 | und | 1.00 |
| 70 | 06.02.04.03 | Panel Informativo H=1.25m. Tipo A | 1d | 2024-04-08 | 2024-04-08 | 69 | 2024-05-15 | 2024-05-15 | 1d | 171.81d |  | finish no later than 2024-09-27 | und | 1.00 |
| 71 | 06.02.04.04 | Panel Informativo H=2.10m. Tipo B | 1d | 2024-04-07 | 2024-04-07 | 69SS | 2024-05-16 | 2024-05-16 | 1d | 175.81d |  | finish no later than 2024-09-30 | und | 1.00 |
| 72 | 6.03 | **Pasarela-Elementos Estructurales** | 55d | 2024-01-02 | 2024-02-25 |  | 2024-03-18 | 2024-05-07 | 37d | 169.81d |  | finish no later than 2024-09-30 |  |  |
| 73 | 06.03.01 | **Trabajos Preliminares** | 2d | 2024-01-02 | 2024-01-03 |  | 2024-03-19 | 2024-03-20 | 2d | 173.81d |  | finish no later than 2024-06-25 |  |  |
| 74 | 06.03.01.01 | Trazo, nivelación y replanteo en pasarela | 1d | 2024-01-02 | 2024-01-02 | 63SS | 2024-03-19 | 2024-03-19 | 1d | 173.81d | 0d | finish no later than 2024-06-24 | m2 | 180.00 |
| 75 | 06.03.01.02 | Movilización y desmovilización de equipos | 1d | 2024-01-03 | 2024-01-03 | 74 | 2024-03-20 | 2024-03-20 | 1d | 173.81d |  | finish no later than 2024-06-25 | glb | 1.00 |

| ID | WBS | Task | Duration | Start | Finish | Predecessors | Baseline start | Baseline finish | Baseline duration | Total slack | Free slack | Constraint | UND | METRADO |
| --- | --- | --- | --- | --- | --- | --- | --- | --- | --- | --- | --- | --- | --- | --- |
| 76 | 06.03.02 | **Movimiento de tierras** | 2d | 2024-02-01 | 2024-02-02 |  | 2024-03-18 | 2024-03-19 | 2d | 139.81d |  | finish no later than 2024-09-27 |  |  |
| 77 | 06.03.02.01 | Excavación con maquinaria | 1d | 2024-02-01 | 2024-02-01 | 43 | 2024-03-18 | 2024-03-19 | 1d | 139.81d | 0d | finish no later than 2024-09-26 | m3 | 30.93 |
| 78 | 06.03.02.02 | Acarreo y eliminación de material excedente | 1d | 2024-02-02 | 2024-02-02 | 77 | 2024-03-19 | 2024-03-19 | 1d | 139.81d | 0d | finish no later than 2024-09-27 | m3 | 27.80 |
| 79 | 06.03.03 | **Rellenos** | 1d | 2024-02-15 | 2024-02-15 |  | 2024-03-20 | 2024-03-20 | 1d | 227.81d |  | finish no later than 2024-09-30 |  |  |
| 80 | 06.03.03.01 | Relleno con material propio | 1d | 2024-02-15 | 2024-02-15 | 82 | 2024-03-20 | 2024-03-20 | 1d | 227.81d |  | finish no later than 2024-09-30 | m3 | 290.43 |
| 81 | 06.03.04 | **Obras de concreto simple** | 12d | 2024-02-03 | 2024-02-14 |  | 2024-03-21 | 2024-04-05 | 12d | 139.81d |  | finish no later than 2024-07-07 |  |  |
| 82 | 06.03.04.01 | Concreto para pilotes F´C=28 Mpa | 2d | 2024-02-13 | 2024-02-14 | 83 | 2024-04-04 | 2024-04-05 | 2d | 143.81d | 0d | finish no later than 2024-07-07 | m3 | 27.81 |
| 83 | 06.03.04.02 | Encofrado y desencofrado en pilotes | 10d | 2024-02-03 | 2024-02-12 | 78 | 2024-03-21 | 2024-04-03 | 10d | 139.81d | 0d | finish no later than 2024-07-05 | m2 | 278.10 |
| 84 | 06.03.05 | **Carpintería de Madera** | 10d | 2024-02-13 | 2024-02-22 |  | 2024-04-04 | 2024-04-17 | 10d | 139.81d |  | finish no later than 2024-09-30 |  |  |
| 85 | 06.03.05.01 | Columna de Ø 8" | 2d | 2024-02-13 | 2024-02-14 | 83 | 2024-04-04 | 2024-04-05 | 2d | 139.81d | 0d | finish no later than 2024-07-07 | und | 63.00 |
| 86 | 06.03.05.02 | Viga de 3"X10" | 2d | 2024-02-15 | 2024-02-16 | 85 | 2024-04-08 | 2024-04-09 | 2d | 216.81d | 0d | finish no later than 2024-09-20 | und | 47.00 |
| 87 | 06.03.05.03 | Larguero de 2"X10" | 3d | 2024-02-17 | 2024-02-19 | 86 | 2024-04-10 | 2024-04-12 | 3d | 218.81d | 0d | finish no later than 2024-09-25 | und | 190.00 |
| 88 | 06.03.05.04 | Arriostres de 3"X8" | 3d | 2024-02-20 | 2024-02-22 | 87 | 2024-04-15 | 2024-04-17 | 3d | 220.81d |  | finish no later than 2024-09-30 | und | 107.00 |
| 89 | 06.03.06 | **Accesorios Metálicos** | 4d | 2024-02-13 | 2024-02-16 |  | 2024-04-03 | 2024-04-04 | 1d | 139.81d |  | finish no later than 2024-09-30 |  |  |
| 90 | 06.03.06.01 | Perno Hexagonal 1/2"X17" + 2 Tuercas + 2 Arandelas | 1d | 2024-02-13 | 2024-02-13 | 85SS | 2024-04-03 | 2024-04-04 | 1d | 139.81d | 0d | finish no later than 2024-09-30 | und | 90.00 |
| 91 | 06.03.06.02 | Perno Hexagonal 5/8"X6" + 2 Tuercas + 2 Arandelas | 1d | 2024-02-14 | 2024-02-14 | 90 | 2024-04-03 | 2024-04-04 | 1d | 139.81d | 0d | finish no later than 2024-09-30 | und | 480.00 |
| 92 | 06.03.06.03 | Perno Hexagonal 3/4"X16" + 2 Tuercas + 2 Arandelas | 1d | 2024-02-15 | 2024-02-15 | 91 | 2024-04-03 | 2024-04-04 | 1d | 139.81d | 0d | finish no later than 2024-09-30 | und | 260.00 |
| 93 | 06.03.06.04 | Perno Hexagonal 1/2"X6.5" + 2 Tuercas + 2 Arandelas | 1d | 2024-02-16 | 2024-02-16 | 92 | 2024-04-03 | 2024-04-04 | 1d | 139.81d | 0d | finish no later than 2024-07-05 | und | 285.00 |
| 94 | 06.03.07 | **Varios** | 9d | 2024-02-17 | 2024-02-25 |  | 2024-04-25 | 2024-05-07 | 9d | 154.81d |  | finish no later than 2024-07-29 |  |  |
| 95 | 06.03.07.01 | Limpieza final de obra | 9d | 2024-02-17 | 2024-02-25 | 93 | 2024-04-25 | 2024-05-07 | 9d | 154.81d |  | finish no later than 2024-07-29 | m2 | 180.00 |
| 96 | 6.04 | **Vivero Forestal** | 60d | 2024-07-01 | 2024-08-29 |  | 2024-05-08 | 2024-05-08 | 1d | -30.19d | 0d | finish no later than 2024-07-30 |  |  |
| 97 | 6.04.01 | Implementación de vivero temporal | 60d | 2024-07-01 | 2024-08-29 |  | 2024-05-08 | 2024-05-08 | 1d | -30.19d | 0d | start no earlier than 2024-07-01 | glb | 1.00 |
| 98 | 6.05 | **Espacio público próximo a bocatoma fortaleza** | 83d | 2024-02-01 | 2024-04-23 |  | 2023-12-01 | 2023-12-01 | 1d | 157.81d |  | finish no later than 2024-09-30 |  |  |
| 99 | 06.05.01 | **Preparación del terreno** | 8d | 2024-02-01 | 2024-02-08 |  | 2023-12-01 | 2023-12-01 | 1d | 157.81d |  | finish no later than 2024-08-07 | m2 | 1,074.97 |
| 100 | 06.05.01.01 | Ubicación y delimitación de la zona de trabajo | 1d | 2024-02-01 | 2024-02-01 | 40SS+30d | 2023-12-01 | 2023-12-01 | 1d | 157.81d | 0d | finish no later than 2024-07-31 | m2 | 1,074.97 |
| 101 | 06.05.01.02 | Trazado, marcación y estacado | 1d | 2024-02-02 | 2024-02-02 | 100 | 2023-12-01 | 2023-12-01 | 1d | 157.81d | 0d | finish no later than 2024-08-01 | m2 | 1,074.97 |
| 102 | 06.05.01.03 | Limpieza y desbroce del terreno con medios manuales | 1d | 2024-02-03 | 2024-02-03 | 101 | 2023-12-01 | 2023-12-01 | 1d | 157.81d | 0d | finish no later than 2024-08-02 | m3 | 65.36 |
| 103 | 06.05.01.04 | Eliminación de materiales de desbroce (Incluye Transporte) | 1d | 2024-02-04 | 2024-02-04 | 102 | 2023-12-01 | 2023-12-01 | 1d | 157.81d | 0d | finish no later than 2024-08-03 | m2 | 270.57 |
| 104 | 06.05.01.05 | Remoción del terreno con medios manuales con profundidad hasta 25 cm | 1d | 2024-02-05 | 2024-02-05 | 103 | 2023-12-01 | 2023-12-01 | 1d | 157.81d | 0d | finish no later than 2024-08-04 | m2 | 270.57 |
| 105 | 06.05.01.06 | Rastrillado del terreno | 1d | 2024-02-06 | 2024-02-06 | 104 | 2023-12-01 | 2023-12-01 | 1d | 157.81d | 0d | finish no later than 2024-08-05 | m2 | 270.57 |
| 106 | 06.05.01.07 | Preparación y aporte del sustrato | 1d | 2024-02-07 | 2024-02-07 | 105 | 2023-12-01 | 2023-12-01 | 1d | 157.81d | 0d | finish no later than 2024-08-06 | mes | 3.00 |
| 107 | 06.05.01.08 | Riego de áreas vegetadas con camión cisterna | 1d | 2024-02-08 | 2024-02-08 | 106 | 2023-12-01 | 2023-12-01 | 1d | 180.81d |  | finish no later than 2024-08-07 |  |  |

| ID | WBS | Task | Duration | Start | Finish | Predecessors | Baseline start | Baseline finish | Baseline duration | Total slack | Free slack | Constraint | UND | METRADO |
| --- | --- | --- | --- | --- | --- | --- | --- | --- | --- | --- | --- | --- | --- | --- |
| 108 | 06.05.02 | **Especies Arbustivas** | 25d | 2024-02-08 | 2024-03-03 |  | 2023-12-01 | 2023-12-01 | 1d | 157.81d |  | finish no later than 2024-08-09 | und | 58.00 |
| 109 | 06.05.02.01 | Galvezia Fruticosa (Galvezia). Incluye siembra y transporte | 25d | 2024-02-08 | 2024-03-03 | 106 | 2023-12-01 | 2023-12-01 | 1d | 157.81d | 0d | finish no later than 2024-08-08 | und | 92.00 |
| 110 | 06.05.02.02 | Bougainvillea Peruviana (Buganvilla). Incluye siembra y transporte | 1d | 2024-02-08 | 2024-02-08 | 109SS | 2023-12-01 | 2023-12-01 | 1d | 180.81d | 0d | finish no later than 2024-08-09 |  |  |
| 111 | 06.05.03 | **Especies arbóreas** | 4d | 2024-02-09 | 2024-02-12 |  | 2023-12-01 | 2023-12-01 | 1d | 180.81d |  | finish no later than 2024-08-11 | und | 2.00 |
| 112 | 06.05.03.01 | Schinus Molle (Molle) Incluye siembra y transporte | 3d | 2024-02-09 | 2024-02-11 | 110 | 2023-12-01 | 2023-12-01 | 1d | 180.81d | 0d | finish no later than 2024-08-10 | und | 7.00 |
| 113 | 06.05.03.02 | Acacia Macracantha (Huarango) Incluye siembra y transporte | 1d | 2024-02-12 | 2024-02-12 | 112 | 2023-12-01 | 2023-12-01 | 1d | 180.81d | 0d | finish no later than 2024-08-11 |  |  |
| 114 | 06.05.04 | **Especies Cubresuelos** | 1d | 2024-02-13 | 2024-02-13 |  | 2023-12-01 | 2023-12-01 | 1d | 180.81d |  | finish no later than 2024-08-12 | m2 | 174.17 |
| 115 | 06.05.04.01 | Lippia Nodiflora (Bella Alfombra) Incluye siembra y transporte | 1d | 2024-02-13 | 2024-02-13 | 113 | 2023-12-01 | 2023-12-01 | 1d | 180.81d |  | finish no later than 2024-08-12 |  |  |
| 116 | 06.05.05 | **Formación de senderos y plataformas** | 35d | 2024-02-04 | 2024-03-09 |  | 2023-12-01 | 2023-12-01 | 1d | 158.81d |  | finish no later than 2024-08-15 | m2 | 724.18 |
| 117 | 06.05.05.01 | Conformación y compactación de base granular de espesor e=0.15m (Incluye material) | 10d | 2024-02-04 | 2024-02-13 | 102 | 2023-12-01 | 2023-12-01 | 1d | 158.81d | 0d | finish no later than 2024-08-13 | m2 | 724.18 |
| 118 | 06.05.05.02 | Capa superficial de arena de espesor e=0.05m | 10d | 2024-02-14 | 2024-02-23 | 117 | 2023-12-01 | 2023-12-01 | 1d | 158.81d | 0d | finish no later than 2024-08-14 |  | 143.94 |
| 119 | 06.05.05.03 | Borde de troncos de madera de altura 15 cm sobre el nivel de piso y altura total 50 cm diámetro 4" | 15d | 2024-02-24 | 2024-03-09 | 118 | 2023-12-01 | 2023-12-01 | 1d | 158.81d |  | finish no later than 2024-08-15 |  |  |
| 120 | 06.05.06 | **Elementos arquitectónicos** | 1d | 2024-04-09 | 2024-04-09 |  | 2023-12-01 | 2023-12-01 | 1d | 128.81d |  | finish no later than 2024-08-16 |  | 124.60 |
| 121 | 06.05.06.01 | Baranda rústica de madera de eucalipto de altura h=1.00 m | 1d | 2024-04-09 | 2024-04-09 | 68FS+2d | 2023-12-01 | 2023-12-01 | 1d | 128.81d |  | finish no later than 2024-08-16 |  |  |
| 122 | 06.05.07 | **Mobiliario urbano** | 17d | 2024-04-07 | 2024-04-23 |  | 2023-12-01 | 2023-12-01 | 1d | 117.81d |  | finish no later than 2024-08-19 | und | 9.00 |
| 123 | 06.05.07.01 | Banca de madera sobre gavión. Tipo T2 | 2d | 2024-04-07 | 2024-04-08 | 68 | 2023-12-01 | 2023-12-01 | 1d | 117.81d | 0d | finish no later than 2024-08-17 | und | 2.00 |
| 124 | 06.05.07.02 | Papeleras de reciclaje de acabado de madera en estructura de 4 (75 litros c/u) | 5d | 2024-04-09 | 2024-04-13 | 123 | 2023-12-01 | 2023-12-01 | 1d | 117.81d | 0d | finish no later than 2024-08-18 | und | 3.00 |
| 125 | 06.05.07.03 | Piedra ornamental para espacio público | 10d | 2024-04-14 | 2024-04-23 | 124 | 2023-12-01 | 2023-12-01 | 1d | 117.81d |  | finish no later than 2024-08-19 |  |  |
| 126 | 06.05.08 | **Señalética Informativa** | 1d | 2024-02-14 | 2024-02-14 |  | 2023-12-01 | 2023-12-01 | 1d | 187.81d |  | finish no later than 2024-08-21 | und | 1.00 |
| 127 | 06.05.08.01 | Panel informativo h=1.25m. tipo a | 1d | 2024-02-14 | 2024-02-14 | 130 | 2023-12-01 | 2023-12-01 | 1d | 187.81d | 0d | finish no later than 2024-08-20 | und | 2.00 |
| 128 | 06.05.08.02 | Panel informativo h=2.10m. tipo b | 1d | 2024-02-14 | 2024-02-14 | 127SS | 2023-12-01 | 2023-12-01 | 1d | 188.81d |  | finish no later than 2024-08-21 |  |  |
| 129 | 06.05.09 | **Señalética Informativa** | 32d | 2024-02-04 | 2024-03-06 |  | 2023-12-01 | 2023-12-01 | 1d | 187.81d |  | finish no later than 2024-09-30 | m3 | 0.75 |
| 130 | 06.05.09.01 | Excavación en material suelto, con equipo | 10d | 2024-02-04 | 2024-02-13 | 102 | 2023-12-01 | 2023-12-01 | 1d | 187.81d | 0d | finish no later than 2024-08-31 | m3 | 0.75 |
| 131 | 06.05.09.02 | Conformación de DME/DMO | 20d | 2024-02-16 | 2024-03-06 | 134 | 2023-12-01 | 2023-12-01 | 1d | 197.81d |  | finish no later than 2024-09-20 | m3 | 0.75 |
| 132 | 06.05.09.03 | Concreto (F'c = 21 mpa) en cimentación | 1d | 2024-02-15 | 2024-02-15 | 133 | 2023-12-01 | 2023-12-01 | 1d | 218.81d | 0d | finish no later than 2024-09-21 | kg | 24.46 |
| 133 | 06.05.09.04 | Acero en barras corrugadas (Fy=420mpa) | 1d | 2024-02-14 | 2024-02-14 | 130 | 2023-12-01 | 2023-12-01 | 1d | 218.81d | 0d | finish no later than 2024-09-22 | m2 | 5.08 |
| 134 | 06.05.09.05 | Encofrado y desencofrado | 1d | 2024-02-15 | 2024-02-15 | 135 | 2023-12-01 | 2023-12-01 | 1d | 197.81d | 0d | finish no later than 2024-09-23 | kg | 22.82 |
| 135 | 06.05.09.06 | Acero estructural A36 | 1d | 2024-02-14 | 2024-02-14 | 130 | 2023-12-01 | 2023-12-01 | 1d | 197.81d | 0d | finish no later than 2024-09-24 | und | 20.00 |
| 136 | 06.05.09.07 | Tornillo galvanizado ø1/4" pasante A307 (Incluido con tuerca y arandela plana) | 1d | 2024-02-16 | 2024-02-16 | 132 | 2023-12-01 | 2023-12-01 | 1d | 221.81d | 0d | finish no later than 2024-09-25 | und | 8.00 |
| 137 | 06.05.09.08 | Perno de anclaje ø1/4" expansivo A307 L=57mm | 1d | 2024-02-17 | 2024-02-17 | 136 | 2023-12-01 | 2023-12-01 | 1d | 221.81d | 0d | finish no later than 2024-09-26 | und | 24.00 |
| 138 | 06.05.09.09 | Perno de anclaje ø1/4" expansivo A307 L=114mm | 1d | 2024-02-18 | 2024-02-18 | 137 | 2023-12-01 | 2023-12-01 | 1d | 221.81d | 0d | finish no later than 2024-09-27 | kg | 1.04 |
| 139 | 06.05.09.10 | Tubo ASTM A500/A500m | 1d | 2024-02-19 | 2024-02-19 | 138 | 2023-12-01 | 2023-12-01 | 1d | 223.81d |  | finish no later than 2024-09-30 |  |  |

| ID | WBS | Task | Duration | Start | Finish | Predecessors | Baseline start | Baseline finish | Baseline duration | Total slack | Free slack | Constraint | UND | METRADO |
| --- | --- | --- | --- | --- | --- | --- | --- | --- | --- | --- | --- | --- | --- | --- |
| 140 | 7.00 | **Colocación de la roca** | 332d | 2023-11-09 | 2024-10-05 |  | 2024-06-14 | 2024-11-20 | 114d | 0d |  | finish no later than 2024-11-20 |  |  |
| 141 | 7.06 | Malla Gavión de 1m x 1m x 5m | 10d | 2024-09-26 | 2024-10-05 | 32 | 2024-11-14 | 2024-11-20 | 5d | 38d |  | finish no later than 2024-11-20 | m3 | 766.47 |
| 142 | 7.07 | Enrocado talud encachado con concreto | 300d | 2023-12-06 | 2024-09-30 | 145SS+20d | 2024-07-01 | 2024-07-05 | 5d | -0.19d | 0d | finish no later than 2024-09-30 | m3 | 177,303.42 |
| 143 | 7.08 | Desmontaje y Recolocación de enrocado | 30d | 2024-08-27 | 2024-09-25 | 142FF-5d | 2024-06-14 | 2024-06-18 | 3d | 48d |  | finish no later than 2024-11-20 | m3 | 353.43 |
| 144 | 7.02 | Colocación de roca en uña | 330d | 2023-11-09 | 2024-10-03 | 35SS+7d | 2024-11-08 | 2024-11-08 | 1d | 0d |  | finish no earlier than 2023-12-08 | m3 | 145,128.07 |
| 145 | 7.03 | Colocación de roca en Talud | 323d | 2023-11-16 | 2024-10-03 | 144SS+7d | 2024-11-11 | 2024-11-11 | 1d | -0.19d | 0d | finish no later than 2024-11-11 | m3 | 31,197.50 |
| 146 | 7.04 | Extracción y selección de Rocas Reutilizables | 50d | 2023-11-16 | 2024-01-04 | 144SS, 145SS | 2024-11-12 | 2024-11-12 | 1d | 278d | 0d | finish no later than 2024-11-12 | m2 | 438.96 |
| 147 | 7.05 | Protección de Talud con Colchón Reno 6m largo x e= 0.30cm | 20d | 2024-01-15 | 2024-02-03 | 146FS+10d | 2024-11-13 | 2024-11-13 | 1d | 278d |  | finish no later than 2024-11-13 | und | 24.00 |
| 148 | 8.00 | **Transportes** | 352d | 2023-10-28 | 2024-10-13 |  | 2024-02-23 | 2024-06-28 | 91d | -25.19d | 0d | finish no later than 2024-09-18 |  |  |
| 149 | 8.01 | Transporte de material orgánico (a DMO) D<=1km | 281d | 2023-10-31 | 2024-10-13 | 4SS+30d | 2024-02-23 | 2024-06-13 | 80d | -25.19d | 0d |  | m3/km | 95,703.80 |
| 150 | 8.02 | Transporte de material orgánico (a DMO) D>1km | 281d | 2023-10-31 | 2024-10-13 | 149SS | 2024-06-14 | 2024-06-14 | 1d | -25.19d | 0d |  | m3/km | 1,083,389.09 |
| 151 | 8.03 | Transporte de material excedente D<=1km | 281d | 2023-10-31 | 2024-10-13 | 150SS | 2024-06-17 | 2024-06-17 | 1d | -25.19d | 0d |  | m3/km | 653,112.02 |
| 152 | 8.04 | Transporte de material excedente D>1km | 281d | 2023-10-31 | 2024-10-13 | 151SS | 2024-06-18 | 2024-06-18 | 1d | -25.19d | 0d |  | m3/km | 7,571,106.10 |
| 153 | 8.05 | Transporte de material de préstamo (afirmado) D<= 1km | 268d | 2023-10-28 | 2024-09-29 | 30SS-5d | 2024-06-19 | 2024-06-19 | 1d | -11.19d | 0d | finish no earlier than 2024-09-02 | m3/km | 195,610.45 |
| 154 | 8.06 | Transporte de material de préstamo (afirmado) D> 1km | 267d | 2023-10-28 | 2024-09-29 | 30SS-5d | 2024-06-20 | 2024-06-20 | 1d | -11.19d | 0d | finish no earlier than 2024-08-08 | m3/km | 2,215,101.63 |
| 155 | 8.07 | Transporte de roca D<=1km | 239.19d | 2023-11-22 | 2024-09-25 | 144SS-5d | 2024-06-21 | 2024-06-21 | 1d | -7d | 0d | finish no earlier than 2024-09-25 | m3/km | 323,179.70 |
| 156 | 8.08 | Transporte de roca D>1km | 211.19d | 2023-11-22 | 2024-08-28 | 155SS | 2024-06-24 | 2024-06-24 | 1d | 21d | 0d | start no earlier than 2023-11-20 | m3/km | 2,707,283.48 |
| 157 | 8.09 | Transporte de material de préstamo cantera de rio (cuerpo de terraplén) D<=1km | 211.19d | 2023-11-22 | 2024-08-28 | 156SS | 2024-06-25 | 2024-06-25 | 1d | 21d | 0d | finish no later than 2024-09-18 | m3/km | 369,812.29 |
| 158 | 8.10 | Transporte de material de préstamo cantera de rio (cuerpo de terraplén) D>1km | 211.19d | 2023-11-22 | 2024-08-28 | 157SS | 2024-06-26 | 2024-06-26 | 1d | 21d | 0d | finish no later than 2024-09-18 | m3/km | 1,479,802.89 |
| 159 | 8.11 | Transporte de material seleccionado para zanja D<=1km | 211.19d | 2023-11-22 | 2024-08-28 | 158SS | 2024-06-27 | 2024-06-27 | 1d | 21d | 0d | finish no later than 2024-09-18 | und | - |
| 160 | 8.12 | Transporte de material seleccionado para zanja D>1km | 211.19d | 2023-11-22 | 2024-08-28 | 159SS | 2024-06-28 | 2024-06-28 | 1d | 21d |  |  | und | 2.00 |
| 161 | 9.00 | **Señalización** | 386d | 2023-10-01 | 2024-10-20 |  | 2024-07-01 | 2024-07-01 | 1d | -111d | 0d | finish no later than 2024-07-01 |  |  |
| 162 | 9.01 | Señalización de obra | 386d | 2023-10-01 | 2024-10-20 |  | 2024-07-01 | 2024-07-01 | 1d | -111d | 0d | start no earlier than 2023-10-01 | glb | 0.00 |
| 163 | 10.00 | **Calidad** | 386d | 2023-10-01 | 2024-10-20 |  | 2023-12-01 | 2024-12-30 | 282d | 51d |  | finish no later than 2024-12-30 |  |  |
| 164 | 10.01 | Control de calidad | 386d | 2023-10-01 | 2024-10-20 |  | 2023-12-01 | 2024-12-30 | 282d | 51d |  | finish no later than 2024-12-30 | glb | 0.00 |

| ID | WBS | Task | Duration | Start | Finish | Predecessors | Baseline start | Baseline finish | Baseline duration | Total slack | Free slack | Constraint | UND | METRADO |
| --- | --- | --- | --- | --- | --- | --- | --- | --- | --- | --- | --- | --- | --- | --- |
| 165 | 11.00 | **Obras Civiles** | 362d | 2023-10-01 | 2024-09-26 |  | 2024-07-02 | 2024-12-19 | 123d | 58d |  | finish no later than 2024-12-19 |  |  |
| 166 | 11.01 | Trazo y replanteo de interferencia | 7d | 2023-11-09 | 2023-11-15 | 28SS+7d | 2024-07-02 | 2024-07-10 | 7d | 19d | 0d | finish no later than 2024-06-17 | m2 | 12,681.09 |
| 167 | 11.02 | Desvío provisional con tubería | 4d | 2023-10-01 | 2023-10-04 |  | 2024-07-11 | 2024-07-11 | 1d | 261d |  | finish no later than 2024-06-21 |  | 593.78 |
| 168 | 11.03 | Desvío provisional en tierras | 5d | 2023-10-01 | 2023-10-05 |  | 2024-07-12 | 2024-07-18 | 5d | 265d |  | finish no later than 2024-06-26 |  | 3,512.14 |
| 169 | 11.04 | Limpieza de terreno manual | 5d | 2023-11-16 | 2023-11-20 | 166 | 2024-07-19 | 2024-07-25 | 5d | 19d | 0d | finish no later than 2024-07-01 | m2 | 12,681.09 |
| 170 | 11.05 | Excavaciones no clasificadas para estructuras | 5d | 2023-11-21 | 2023-11-25 | 169 | 2024-07-05 | 2024-07-11 | 5d | 19d | 0d | finish no later than 2024-07-06 | m3 | 1,645.55 |
| 171 | 11.06 | Excavación no clasificada de zanja | 5d | 2023-11-26 | 2023-11-30 | 170 | 2024-07-05 | 2024-07-12 | 5d | 19d | 0d | finish no later than 2024-07-11 | m3 | 4,574.17 |
| 172 | 11.07 | Relleno estructural | 5d | 2023-12-01 | 2023-12-05 | 171 | 2024-07-12 | 2024-07-18 | 5d | 226d | 0d | finish no later than 2024-07-18 | m3 | 3,311.97 |
| 173 | 11.08 | Suministro de roca (Alcantarillas) | 5d | 2023-12-01 | 2023-12-05 | 172SS | 2024-07-19 | 2024-07-25 | 5d | 292.81d | 0d | finish no later than 2024-09-23 | m3 | 1,208.86 |
| 174 | 11.09 | Colocación de roca en uña (Alcantarillas) | 5d | 2023-12-06 | 2023-12-10 | 173 | 2024-07-26 | 2024-08-01 | 5d | 294.81d |  | finish no later than 2024-09-30 | m3 | 1,208.86 |
| 175 | 11.10 | Concreto de Nivelación (f'c=100 kg/cm2) | 10d | 2024-05-24 | 2024-06-02 | 171FS+175d | 2024-07-12 | 2024-07-18 | 5d | 19d | 0d | finish no later than 2024-07-18 | m3 | 165.72 |
| 176 | 11.11 | Concreto Clase F (f'c=140 kg/cm2) | 10d | 2024-06-03 | 2024-06-12 | 175 | 2024-07-19 | 2024-07-25 | 5d | 19d | 0d | finish no later than 2024-09-30 | m3 | 163.38 |
| 177 | 11.12 | Concreto Clase C (f'c=280 kg/cm2) Premezclado - Cimientos reforzados | 10d | 2024-06-13 | 2024-06-22 | 176 | 2024-07-12 | 2024-07-18 | 5d | 19d | 0d | finish no later than 2024-07-18 | m3 | 229.60 |
| 178 | 11.13 | Concreto Clase C (f'c=280 kg/cm2) Premezclado - Muros de contención | 10d | 2024-06-23 | 2024-07-02 | 177 | 2024-07-19 | 2024-07-19 | 1d | 19d | 0d | finish no later than 2024-09-30 | m3 | 352.41 |
| 179 | 11.14 | Encofrado y Desencofrado Caravista | 15d | 2024-05-24 | 2024-06-07 | 175SS | 2024-07-16 | 2024-07-16 | 1d | 39d | 0d | finish no later than 2024-09-30 | m2 | 699.17 |
| 180 | 11.15 | Encofrado y Desencofrado Cara Oculta | 30d | 2024-05-26 | 2024-06-24 | 179SS+2d | 2024-07-15 | 2024-07-15 | 1d | 39d | 0d | finish no later than 2024-09-27 | m2 | 1,359.80 |
| 181 | 11.16 | Acero de refuerzo f'y=4200kg/cm2 | 30d | 2023-11-09 | 2023-12-08 | 166SS | 2024-07-12 | 2024-07-12 | 1d | 292.81d |  | finish no later than 2024-09-26 | kg | 32,669.39 |
| 182 | 11.17 | Emboquillado de piedra e=0.20m | 30d | 2024-06-25 | 2024-07-24 | 180 | 2024-07-12 | 2024-10-03 | 60d | 41d | 0d | finish no later than 2024-10-03 | m2 | 2,050.24 |
| 183 | 11.18 | Emboquillado de piedra e=0.30m | 30d | 2024-07-10 | 2024-08-08 | 182SS+15d | 2024-07-12 | 2024-10-03 | 60d | 41d | 0d | finish no later than 2024-10-03 | m2 | 656.81 |
| 184 | 11.19 | Emboquillado de piedra e=0.50m | 30d | 2024-07-25 | 2024-08-23 | 183SS+15d | 2024-07-12 | 2024-10-03 | 60d | 41d |  | finish no later than 2024-10-03 | m2 | 154.41 |
| 185 | 11.20 | Cama de arena e=0.20m | 4d | 2024-09-23 | 2024-09-26 | 20 | 2024-10-04 | 2024-10-09 | 4d | 13d |  | finish no later than 2024-10-09 | m2 | 387.14 |
| 186 | 11.21 | Tubería HDPE Corrugada Ø=600mm (Suministro e instalación) | 2d | 2023-11-12 | 2023-11-13 | 31SS+10d | 2024-10-10 | 2024-10-11 | 2d | 278d | 0d | finish no later than 2024-10-11 |  | - |
| 187 | 11.22 | Tubería HDPE Corrugada Ø=900mm (Suministro e instalación) | 5d | 2023-11-14 | 2023-11-18 | 186 | 2024-10-14 | 2024-10-18 | 5d | 278d | 0d | finish no later than 2024-10-18 |  | 161.89 |
| 188 | 11.23 | Tubería HDPE Corrugada Ø=1200mm (Suministro e instalación) | 1d | 2023-11-19 | 2023-11-19 | 187 | 2024-10-21 | 2024-10-21 | 1d | 278d | 0d | finish no later than 2024-10-21 |  | 41.89 |
| 189 | 11.24 | Tubería HDPE Corrugada Ø=1500mm (Suministro e instalación) | 1d | 2023-11-20 | 2023-11-20 | 188 | 2024-10-22 | 2024-10-22 | 1d | 278d | 0d | finish no later than 2024-10-22 |  | - |
| 190 | 11.25 | Compuertas Charnela Ø600 (Suministro e instalación) | 2d | 2023-11-21 | 2023-11-22 | 189 | 2024-10-23 | 2024-10-24 | 2d | 278d | 0d | finish no later than 2024-10-24 | und | - |
| 191 | 11.26 | Compuertas Charnela Ø900 (Suministro e instalación) | 2d | 2023-11-23 | 2023-11-24 | 190 | 2024-10-25 | 2024-10-28 | 2d | 285d | 0d | finish no later than 2024-10-28 | und | 7.00 |
| 192 | 11.27 | Compuertas Charnela Ø1200 (Suministro e instalación) | 2d | 2023-11-25 | 2023-11-26 | 191 | 2024-10-29 | 2024-10-30 | 2d | 337d | 0d | finish no later than 2024-10-30 | und | 3.00 |
| 193 | 11.28 | Compuertas Charnela Ø1500 (Suministro e instalación) | 2d | 2023-11-27 | 2023-11-28 | 192 | 2024-10-31 | 2024-11-01 | 2d | 337d | 0d | finish no later than 2024-11-01 | und | - |
| 194 | 11.29 | Compuerta metálica tipo tarjeta 1.00x1.00m (Suministro e instalación) | 2d | 2023-11-29 | 2023-11-30 | 193 | 2024-11-04 | 2024-11-05 | 2d | 337d | 0d | finish no later than 2024-11-05 | und | 2.00 |
| 195 | 11.30 | Sello en juntas | 5d | 2023-12-01 | 2023-12-05 | 194 | 2024-11-06 | 2024-11-12 | 5d | 337d | 0d | finish no later than 2024-11-12 |  | 992.45 |
| 196 | 11.31 | Waterstop (anillos de estanqueidad) | 7d | 2023-12-06 | 2023-12-12 | 195 | 2024-11-13 | 2024-11-21 | 7d | 337d | 0d | finish no later than 2024-11-21 | und | 30.00 |
| 197 | 11.32 | Pintura bituminosa | 5d | 2023-12-13 | 2023-12-17 | 196 | 2024-11-22 | 2024-11-28 | 5d | 337d |  | finish no later than 2024-11-28 | m2 | 1,212.39 |
| 198 | 11.33 | Relleno con material granular (incluye extracción de material, zarandeo y combinación de material) | 12d | 2023-12-06 | 2023-12-17 | 195 | 2024-11-29 | 2024-12-19 | 15d | 352d |  | finish no later than 2024-12-19 | m3 | 605.22 |
| 199 | 11.34 | Suministro e Instalación de geotextil | 25d | 2024-07-03 | 2024-07-27 | 178 | 2024-07-12 | 2024-08-15 | 25d | 19d |  | finish no later than 2024-08-15 | m2 | 401.56 |
| 200 | 11.35 | Concreto Clase D (f'c=210 kg/cm2) Premezclado - Cimientos reforzados | 5d | 2024-07-10 | 2024-07-14 | 180FS+15d | 2024-08-16 | 2024-08-22 | 5d | 39d |  | finish no later than 2024-08-22 | m3 | - |
| 201 | 11.36 | Rejilla metálica de 1.70x1.50 m (Suministro e instalación) | 9d | 2023-11-23 | 2023-12-01 | 190 | 2024-08-23 | 2024-09-04 | 9d | 278d | 0d | finish no later than 2024-09-04 | und | - |
| 202 | 11.37 | Baranda metálica en acero Ø1 ½” h=1.00m | 1d | 2023-11-25 | 2023-11-25 | 191 | 2024-09-05 | 2024-09-05 | 1d | 285d |  | finish no later than 2024-09-05 | und | 2.00 |
| 203 | 11.38 | Juntas de dilatación | 1d | 2024-07-03 | 2024-07-03 | 178 | 2024-09-06 | 2024-09-06 | 1d | 65d |  | finish no later than 2024-09-06 |  | - |
| 204 | 11.39 | Rejilla metálica de 2.2mx1.50m (Suministro e instalación) | 1d | 2023-12-02 | 2023-12-02 | 201 | 2024-09-09 | 2024-09-09 | 1d | 282d | 0d | finish no later than 2024-09-09 | und | 1.00 |
| 205 | 11.40 | Rejilla metálica de 2.8mx1.50m (Suministro e instalación) | 1d | 2023-12-03 | 2023-12-03 | 204 | 2024-09-10 | 2024-09-10 | 1d | 282d | 0d | finish no later than 2024-09-10 | und | 1.00 |
| 206 | 11.41 | Rejilla metálica de 2.2mx1.80m (Suministro e instalación) | 1d | 2023-12-04 | 2023-12-04 | 205 | 2024-09-11 | 2024-09-11 | 1d | 282d | 0d | finish no later than 2024-09-11 | und |  |
| 207 | 11.42 | Compuerta metálica Tipo Tarjeta 1.4mx1.40m (Suministro e instalación) | 1d | 2023-12-05 | 2023-12-05 | 206 | 2024-09-12 | 2024-09-12 | 1d | 282d |  | finish no later than 2024-09-12 | und | 1.00 |

| ID | WBS | Task | Type | Duration | Start | Finish | Predecessors | Baseline start | Baseline finish | Baseline duration | Total slack | Free slack | Constraint | UND | METRADO |
| --- | --- | --- | --- | --- | --- | --- | --- | --- | --- | --- | --- | --- | --- | --- | --- |
| 208 | 12.00 | **Accesos** |  | 125d | 2024-01-29 | 2024-06-01 |  | 2024-09-13 | 2025-02-07 | 106d | 186d |  | finish no later than 2025-02-07 |  |  |
| 209 | 12.01 | Superficie de rodadura |  | 54d | 2024-02-19 | 2024-04-12 | 210 | 2024-09-13 | 2024-11-27 | 54d | 186d | 0d | finish no later than 2024-10-15 |  |  |
| 210 | 12.01.01 | Concreto clase C (f'c=280 kg/cm2) en losa |  | 4d | 2024-02-15 | 2024-02-18 | 211 | 2024-11-28 | 2024-12-03 | 4d | 186d | 0d | finish no later than 2024-12-03 | m3 | 175.92 |
| 211 | 12.01.02 | Encofrado y desencofrado pavimento rígido e=0.15m |  | 17d | 2024-01-29 | 2024-02-14 | 4SS+120d | 2024-10-04 | 2024-11-07 | 25d | 186d | 0d | finish no later than 2024-11-07 |  | 616.00 |
| 212 | 12.01.03 | Junta en Pavimentos con Pasadores |  | 30d | 2024-04-13 | 2024-05-12 | 209 | 2024-11-08 | 2025-01-10 | 46d | 221d | 0d | finish no later than 2025-01-10 |  | 353.00 |
| 213 | 12.01.04 | Concreto Ciclopeo f'c=210 kg/cm2 + 30% PM |  | 20d | 2024-05-13 | 2024-06-01 | 212 | 2025-01-13 | 2025-02-07 | 20d | 221d |  | finish no later than 2025-02-07 | m3 | 14.80 |
| 214 | 13.00 | **Medio Ambiente** |  | 391d | 2023-10-01 | 2024-10-25 |  | 2023-12-01 | 2025-01-13 | 292d | 39d |  | finish no later than 2025-01-13 |  |  |
| 215 | 13.01 | Mitigación ambiental |  | 90d | 2023-10-01 | 2024-10-25 | 4SS | 2023-12-01 | 2024-12-30 | 282d | 39d | 0d | finish no later than 2024-12-19 |  |  |
| 216 | 13.01.01 | Rescate camaron |  | 20d | 2023-11-30 | 2023-12-19 | 215SS+60d | 2024-12-31 | 2025-01-13 | 10d | 367d |  | finish no later than 2025-01-13 | glb | 1.00 |
| 217 | 14.00 | **Muros** |  | 136d | 2024-05-01 | 2024-09-13 |  | 2024-04-19 | 2024-10-18 | 131d | 12d |  | finish no later than 2024-10-18 |  |  |
| 218 | 14.01 | Concreto de Nivelacion (f'c=100 kg/cm2) |  | 10d | 2024-06-30 | 2024-07-09 | 221 | 2024-07-12 | 2024-08-08 | 20d | 26d | 0d | finish no later than 2024-09-30 | m3 | 537.52 |
| 219 | 14.02 | Concreto Clase C (f'c=280 kg/cm2) Premezclado - Cimientos reforzados |  | 10d | 2024-07-10 | 2024-07-19 | 218 | 2024-08-23 | 2024-10-03 | 30d | 26d | 0d | finish no later than 2024-10-03 | m3 | 3,568.58 |
| 220 | 14.03 | Concreto Clase C (f'c=280 kg/cm2) Premezclado - Muros de contencion |  | 50d | 2024-07-20 | 2024-09-07 | 219 | 2024-07-12 | 2024-10-03 | 60d | 26d |  | finish no later than 2024-10-03 | m3 | 3,328.30 |
| 221 | 14.04 | Encofrado y Desencofrado Caravista |  | 60d | 2024-05-01 | 2024-06-29 | 4SS+213d | 2024-04-19 | 2024-07-11 | 60d | 12d | 0d | finish no later than 2024-07-11 | m2 | 12,692.07 |
| 222 | 14.05 | Encofrado y Desencofrado Cara Oculta |  | 30d | 2024-05-01 | 2024-05-30 | 4SS+213d | 2024-07-12 | 2024-08-22 | 30d | 84d |  | finish no later than 2024-08-22 | m2 | 4,109.17 |
| 223 | 14.06 | Acero de refuerzo f'y=4200kg/cm2 |  | 51d | 2024-06-30 | 2024-08-19 | 221 | 2024-07-12 | 2024-09-20 | 51d | 32d | 0d | finish no later than 2024-09-20 | kg | 356,965.04 |
| 224 | 14.07 | Juntas de dilatación |  | 19d | 2024-08-20 | 2024-09-07 | 223 | 2024-09-23 | 2024-10-17 | 19d | 35d | 0d | finish no later than 2024-10-17 |  | 767.30 |
| 225 | 14.08 | Pintura bituminosa |  | 6d | 2024-09-08 | 2024-09-13 | 224 | 2024-10-11 | 2024-10-18 | 6d | 35d |  | finish no later than 2024-10-18 | m2 | 10,251.31 |
| 226 | 15.00 | **Otros** |  | 60d | 2024-07-20 | 2024-09-17 |  | 2024-10-04 | 2025-01-13 | 72d | 94d |  | finish no later than 2025-01-13 |  |  |
| 227 | 15.01 | Calibración de estación hidrométrica |  | 60d | 2024-07-20 | 2024-09-17 |  | 2024-10-04 | 2024-12-26 | 60d | 94d | 0d | start no earlier than 2024-07-20 | und | 1.00 |
| 228 | 15.02 | Retiro y reubicación de postes de canotaje |  | 45d | 2024-07-20 | 2024-09-02 | 227SS | 2024-10-04 | 2024-12-05 | 45d | 107d |  | finish no later than 2025-01-09 | und | 34.00 |
| 229 | 16 | fin | milestone | 0d | 2024-10-25 | 2024-10-25 |  | 2024-12-31 | 2024-12-31 | 0d | 1d |  | start no earlier than 2024-10-25 |  |  |
